# BB-03 - gietbouw wand+vloerkist

Schedule from MS Project, 2003-01-12 to 2003-02-02, status date 2003-01-08.
BAM Nelissen Van Egteren

## Calendars

- ALLEEN WERKDAGEN: Mon-Fri 08:30-12:30, 13:00-17:00; Sat-Sun off. Exceptions (off unless hours are given): 2003-01-11 to 2003-01-12 08:30-12:30, 13:00-17:00, 2003-01-18 to 2003-01-19 08:30-12:30, 13:00-17:00, 2003-01-25 to 2003-01-26 08:30-12:30, 13:00-17:00, 2003-02-01 to 2003-02-02 08:30-12:30, 13:00-17:00.

## Schedule

| ID | WBS | Task | Type | Duration | Start | Finish | Predecessors | Total slack |
| --- | --- | --- | --- | --- | --- | --- | --- | --- |
| 1 | 1 | **BOVENBOUWFASE** |  | 22d | 2003-01-12 | 2003-02-02 |  | 0d |
| 2 | 1.1 | beg.grond wandkist stellen+wap |  | 5d | 2003-01-12 | 2003-01-16 |  | 0d |
| 3 | 1.2 | beg.grond wanden beton storten |  | 5d | 2003-01-13 | 2003-01-17 | 2SS+1d | 0d |
| 4 | 1.3 | 1e verd. vloerkist stellen+wap |  | 5d | 2003-01-16 | 2003-01-20 | 3SS+3d | 0d |
| 5 | 1.4 | 1e verd. vloer beton storten |  | 5d | 2003-01-17 | 2003-01-21 | 4SS+1d | 0d |
| 6 | 1.5 | 1e verd. wanden stellen+wap |  | 5d | 2003-01-20 | 2003-01-24 | 5SS+3d | 0d |
| 7 | 1.6 | 1e verd. wanden beton storten |  | 5d | 2003-01-21 | 2003-01-25 | 6SS+1d | 0d |
| 8 | 1.7 | zoldervloer vloerkist stellen+wap |  | 5d | 2003-01-24 | 2003-01-28 | 7SS+3d | 0d |
| 9 | 1.8 | zoldervloer beton storten |  | 5d | 2003-01-25 | 2003-01-29 | 8SS+1d | 0d |
| 10 | 1.9 | toppen wandkist stellen+wap |  | 5d | 2003-01-28 | 2003-02-01 | 9SS+3d | 0d |
| 11 | 1.10 | toppen wandkist beton storten |  | 5d | 2003-01-29 | 2003-02-02 | 10SS+1d | 0d |
| 12 | 1.11 | start gevels+daken | milestone | 0d | 2003-02-02 | 2003-02-02 | 11SS+5d | 0d |
